# HarmonogramA

Schedule from MS Project, 2018-11-15 to 2019-10-04.
Hewlett-Packard

## Calendars

- Standardní: Mon-Sat 09:00-13:00, 14:00-18:00; Sun off. Exceptions (off unless hours are given): 2018-12-24 to 2018-12-26 (Vánoce), 2019-01-01 (Nový rok).

## Resources

| Resource |
| --- |
| Zedník |

## Schedule

| ID | WBS | Task | Duration | Start | Finish | Predecessors | Total slack | Free slack |
| --- | --- | --- | --- | --- | --- | --- | --- | --- |
| 1 | 1 | **Bytový dům - Zlatý kopec** | 274d | 2018-11-15 | 2019-10-04 |  | 0d |  |
| 2 | 1.1 | **Přípravné práce** | 7d | 2018-11-15 | 2018-11-22 |  | 0d |  |
| 3 | 1.1.1 | Předání a převzetí staveniště | 1d | 2018-11-15 | 2018-11-15 |  | 0d |  |
| 4 | 1.1.2 | Vybudování zařízení staveniště | 2d | 2018-11-16 | 2018-11-17 | 3 | 0d |  |
| 5 | 1.1.3 | Napojení ZS - na provizorní el. Síť | 2d | 2018-11-19 | 2018-11-20 | 4 | 26d | 0d |
| 6 | 1.1.4 | Napojení ZS - na provizorní vodovod | 2d | 2018-11-21 | 2018-11-22 | 5 | 26d |  |
| 7 | 1.2 | **Zemní práce** | 32d | 2018-11-19 | 2018-12-28 |  | 0d |  |
| 8 | 1.2.1 | Vytyčení objektu | 1d | 2018-11-19 | 2018-11-19 | 4 | 0d |  |
| 9 | 1.2.2 | Piloty | 19d | 2018-11-20 | 2018-12-11 | 8 | 0d |  |
| 10 | 1.2.3 | Sejmutí ornice | 2d | 2018-12-12 | 2018-12-13 | 9 | 0d |  |
| 11 | 1.2.4 | Výkop jámy | 4d | 2018-12-14 | 2018-12-18 | 10 | 0d |  |
| 12 | 1.2.5 | Vytyčení zákl. desky, pasů a šachet | 1d | 2018-12-19 | 2018-12-19 | 11 | 0d |  |
| 13 | 1.2.6 | Výkop zákl. desky, pasů a šachet | 1d | 2018-12-20 | 2018-12-20 | 12 | 0d |  |
| 14 | 1.2.7 | Ruční dotěžení | 1d | 2018-12-21 | 2018-12-21 | 13 | 0d |  |
| 15 | 1.2.8 | Ležatá kanalizace | 4d | 2018-12-21 | 2018-12-28 | 13 | 2d |  |
| 16 | 1.3 | **Základy** | 33d | 2018-12-22 | 2019-02-02 |  | 0d |  |
| 17 | 1.3.1 | Hutněný podsyp pod základovou zdí a šachtou | 1d | 2018-12-22 | 2018-12-22 | 14 | 0d |  |
| 18 | 1.3.2 | Podkladní beton pod zákl. zdí a šachtou | 1d | 2018-12-27 | 2018-12-27 | 17, 5, 6 | 0d |  |
| 19 | 1.3.3 | Základová zeď ze ztraceného bednění | 3d | 2018-12-28 | 2018-12-31 | 18 | 0d |  |
| 20 | 1.3.4 | Zásyp jam, rýh, šachet se zhutněním | 2d | 2019-01-02 | 2019-01-03 | 15, 19FS+1ed | 0d |  |
| 21 | 1.3.5 | Hutněný násyp | 2d | 2019-01-04 | 2019-01-05 | 20 | 0d |  |
| 22 | 1.3.6 | Podkladní beton | 2d | 2019-01-07 | 2019-01-08 | 21 | 0d |  |
| 23 | 1.3.7 | Odbednění podkladního betonu | 1d | 2019-01-10 | 2019-01-10 | 22FS+1ed | 103d | 3d |
| 24 | 1.3.8 | Hydroizolace dna šachet | 1d | 2019-01-05 | 2019-01-05 | 18FS+4ed, 19FS+4ed | 3d | 0d |
| 25 | 1.3.9 | Hydroizolace stěn šachet | 1d | 2019-01-07 | 2019-01-07 | 24, 19FS+4ed | 3d | 0d |
| 26 | 1.3.10 | Vodorovná hydroizolace | 8d | 2019-01-12 | 2019-01-21 | 22FS+3ed, 25 | 0d |  |
| 27 | 1.3.11 | Armování ŽB dna šachet | 1d | 2019-01-08 | 2019-01-08 | 25 | 3d | 0d |
| 28 | 1.3.12 | Betonáž ŽB dna šachet | 1d | 2019-01-09 | 2019-01-09 | 27 | 3d | 0d |
| 29 | 1.3.13 | Armování ŽB stěn šachet | 1d | 2019-01-10 | 2019-01-10 | 28 | 3d | 0d |
| 30 | 1.3.14 | Bednění ŽB stěn šachet | 1d | 2019-01-11 | 2019-01-11 | 29 | 3d | 0d |
| 31 | 1.3.15 | Betonáž ŽB stěn šachet | 1d | 2019-01-12 | 2019-01-12 | 30 | 3d | 0d |
| 32 | 1.3.16 | Odbednění ŽB stěn šachet | 1d | 2019-01-15 | 2019-01-15 | 31FS+2ed, 23 | 100d | 11d |
| 33 | 1.3.17 | Bednění ŽB zákl. desky | 1d | 2019-01-14 | 2019-01-14 | 31 | 3d |  |
| 34 | 1.3.18 | A - Armování ŽB zákl. desky | 7d | 2019-01-18 | 2019-01-25 | 33, 26FS-3d | 0d |  |
| 35 | 1.3.19 | A - Betonáž ŽB zákl. desky | 1d | 2019-01-26 | 2019-01-26 | 34 | 0d |  |
| 36 | 1.3.20 | A - Odbednění ŽB zákl. desky | 1d | 2019-01-29 | 2019-01-29 | 32, 35FS+2ed | 89d | 3d |
| 37 | 1.3.21 | B - Armování ŽB zákl. desky | 3d | 2019-01-26 | 2019-01-29 | 34 | 0d |  |
| 38 | 1.3.22 | B - Betonáž ŽB zákl. desky | 1d | 2019-01-30 | 2019-01-30 | 37, 35 | 87d | 0d |
| 39 | 1.3.23 | B - Odbednění ŽB zákl. desky | 1d | 2019-02-02 | 2019-02-02 | 36, 38FS+2ed | 86d | 3d |

| ID | WBS | Task | Duration | Start | Finish | Predecessors | Total slack | Free slack |
| --- | --- | --- | --- | --- | --- | --- | --- | --- |
| 40 | 1.4 | **Hrubá vrchní stavba** | 101d | 2019-01-28 | 2019-05-24 |  | 0d |  |
| 41 | 1.4.1 | Montáž jeřábu | 1d | 2019-01-28 | 2019-01-28 | 5, 35 | 1d |  |
| 42 | 1.4.2 | **1.NP - sekce A** | 47d | 2019-01-28 | 2019-03-22 |  | 0d |  |
| 43 | 1.4.2.1 | Bednění ŽB stěny a pilířů | 18d | 2019-01-28 | 2019-02-16 | 35 | 0d |  |
| 44 | 1.4.2.2 | Armování ŽB stěny a pilířů | 24d | 2019-01-30 | 2019-02-26 | 43SS+2d, 41, 37 | 0d |  |
| 45 | 1.4.2.3 | Dobednění ŽB stěny | 23d | 2019-02-01 | 2019-02-27 | 44SS+2d | 0d |  |
| 46 | 1.4.2.4 | Betonáž Z1 | 1d | 2019-02-04 | 2019-02-04 | 45SS+2d | 4d | 0d |
| 47 | 1.4.2.5 | Odbednění Z1 | 1d | 2019-02-07 | 2019-02-07 | 39, 46SS+3ed | 83d | 2d |
| 48 | 1.4.2.6 | Betonáž Z2 | 1d | 2019-02-07 | 2019-02-07 | 46SS+3d | 4d | 0d |
| 49 | 1.4.2.7 | Odbednění Z2 | 1d | 2019-02-11 | 2019-02-11 | 47, 48SS+3ed | 81d | 2d |
| 50 | 1.4.2.8 | Betonáž Z3 | 1d | 2019-02-11 | 2019-02-11 | 48SS+3d | 4d | 0d |
| 51 | 1.4.2.9 | Odbednění Z3 | 1d | 2019-02-14 | 2019-02-14 | 49, 50SS+3ed | 79d | 2d |
| 52 | 1.4.2.10 | Betonáž Z4 | 1d | 2019-02-14 | 2019-02-14 | 50SS+3d | 4d | 0d |
| 53 | 1.4.2.11 | Odbednění Z4 | 1d | 2019-02-18 | 2019-02-18 | 52SS+3ed, 51 | 77d | 2d |
| 54 | 1.4.2.12 | Betonáž Z5 | 1d | 2019-02-18 | 2019-02-18 | 52SS+3d | 4d | 0d |
| 55 | 1.4.2.13 | Odbednění Z5 | 1d | 2019-02-21 | 2019-02-21 | 53, 54SS+3ed | 75d | 2d |
| 56 | 1.4.2.14 | Betonáž Z6 | 1d | 2019-02-21 | 2019-02-21 | 54SS+3d | 4d | 0d |
| 57 | 1.4.2.15 | Odbednění Z6 | 1d | 2019-02-25 | 2019-02-25 | 55, 56SS+3ed | 73d | 2d |
| 58 | 1.4.2.16 | Betonáž Z7 | 1d | 2019-02-25 | 2019-02-25 | 56SS+3d | 4d | 0d |
| 59 | 1.4.2.17 | Odbednění Z7 | 1d | 2019-02-28 | 2019-02-28 | 57, 58SS+3ed | 71d | 2d |
| 60 | 1.4.2.18 | Betonáž Z8 | 1d | 2019-02-28 | 2019-02-28 | 58SS+3d | 4d | 1d |
| 61 | 1.4.2.19 | Odbednění Z8 | 1d | 2019-03-04 | 2019-03-04 | 59, 60SS+3ed | 69d | 2d |
| 62 | 1.4.2.20 | Podstojkování ŽB stropu | 2d | 2019-03-09 | 2019-03-11 | 69 | 0d |  |
| 63 | 1.4.2.21 | Bednění ŽB stropu | 4d | 2019-03-11 | 2019-03-14 | 62FS-1d, 70 | 0d |  |
| 64 | 1.4.2.22 | Armování ŽB stropu | 4d | 2019-03-12 | 2019-03-15 | 63SS+1d | 0d |  |
| 65 | 1.4.2.23 | Betonáž ŽB stropu | 1d | 2019-03-16 | 2019-03-16 | 64 | 0d |  |
| 66 | 1.4.2.24 | Odbednění ŽB stropu | 1d | 2019-03-22 | 2019-03-22 | 65FS+5ed, 78 | 58d | 2d |

| ID | WBS | Task | Duration | Start | Finish | Predecessors | Total slack | Free slack |
| --- | --- | --- | --- | --- | --- | --- | --- | --- |
| 67 | 1.4.3 | **1.NP - sekce - B** | 23d | 2019-02-28 | 2019-03-26 |  | 0d |  |
| 68 | 1.4.3.1 | Bednění ŽB stěny | 6d | 2019-02-28 | 2019-03-06 | 45 | 0d |  |
| 69 | 1.4.3.2 | Armování ŽB stěny a pilířů | 8d | 2019-02-28 | 2019-03-08 | 68SS, 44FS+1d | 0d |  |
| 70 | 1.4.3.3 | Dobednění ŽB stěny | 7d | 2019-03-02 | 2019-03-09 | 69SS+2d | 0d |  |
| 71 | 1.4.3.4 | Betonáž Z1 | 1d | 2019-03-04 | 2019-03-04 | 60, 70SS+1d | 2d | 0d |
| 72 | 1.4.3.5 | Odbednění Z1 | 1d | 2019-03-07 | 2019-03-07 | 61, 71SS+3ed | 67d | 1d |
| 73 | 1.4.3.6 | Betonáž Z2 | 1d | 2019-03-06 | 2019-03-06 | 71FS+1d | 2d | 0d |
| 74 | 1.4.3.7 | Odbednění Z2 | 1d | 2019-03-09 | 2019-03-09 | 72, 73SS+3ed | 66d | 0d |
| 75 | 1.4.3.8 | Betonáž Z3 | 1d | 2019-03-08 | 2019-03-08 | 73FS+1d | 2d | 0d |
| 76 | 1.4.3.9 | Odbednění Z3 | 1d | 2019-03-11 | 2019-03-11 | 74, 75SS+3ed | 66d | 2d |
| 77 | 1.4.3.10 | Betonáž Z4 | 1d | 2019-03-11 | 2019-03-11 | 75FS+1d | 2d | 0d |
| 78 | 1.4.3.11 | Odbednění Z4 | 1d | 2019-03-14 | 2019-03-14 | 76, 77SS+3ed | 64d | 6d |
| 79 | 1.4.3.12 | Podstojkování ŽB stropu | 1d | 2019-03-12 | 2019-03-12 | 77 | 2d |  |
| 80 | 1.4.3.13 | Bednění ŽB stropu | 2d | 2019-03-15 | 2019-03-16 | 79, 63 | 0d |  |
| 81 | 1.4.3.14 | Armování ŽB stropu | 3d | 2019-03-16 | 2019-03-19 | 80SS+1d, 64 | 0d |  |
| 82 | 1.4.3.15 | Betonáž ŽB stropu | 1d | 2019-03-20 | 2019-03-20 | 81 | 13d | 0d |
| 83 | 1.4.3.16 | Odbednění ŽB stropu | 1d | 2019-03-26 | 2019-03-26 | 82FS+5ed, 66 | 56d | 16d |
| 84 | 1.4.4 | **2.NP - sekce A** | 25d | 2019-03-18 | 2019-04-15 |  | 0d |  |
| 85 | 1.4.4.1 | Bednění ŽB stěny | 7d | 2019-03-18 | 2019-03-25 | 80, 65 | 0d |  |
| 86 | 1.4.4.2 | Armování ŽB stěny | 10d | 2019-03-20 | 2019-03-30 | 85SS+2d, 81 | 0d |  |
| 87 | 1.4.4.3 | Dobednění ŽB stěny | 8d | 2019-03-22 | 2019-03-30 | 86SS+2d | 0d |  |
| 88 | 1.4.4.4 | Betonáž Z1 | 1d | 2019-03-25 | 2019-03-25 | 87SS+2d | 0d |  |
| 89 | 1.4.4.5 | Odbednění Z1 | 1d | 2019-03-28 | 2019-03-28 | 88SS+3ed | 5d | 2d |
| 90 | 1.4.4.6 | Betonáž Z2 | 1d | 2019-03-28 | 2019-03-28 | 88FS+2d | 0d |  |
| 91 | 1.4.4.7 | Odbednění Z2 | 1d | 2019-04-01 | 2019-04-01 | 89, 90SS+3ed | 3d | 2d |
| 92 | 1.4.4.8 | Betonáž Z3 | 1d | 2019-04-01 | 2019-04-01 | 90FS+2d | 0d |  |
| 93 | 1.4.4.9 | Odbednění Z3 | 1d | 2019-04-04 | 2019-04-04 | 91, 92SS+3ed | 1d |  |
| 94 | 1.4.4.10 | Zdění nosného zdiva | 6d | 2019-03-26 | 2019-04-01 | 88 | 0d |  |
| 95 | 1.4.4.11 | Podstojkování ŽB stropu | 2d | 2019-04-01 | 2019-04-02 | 79, 86, 87 | 0d |  |
| 96 | 1.4.4.12 | Bednění ŽB stropu | 4d | 2019-04-02 | 2019-04-05 | 95SS+1d, 94, 92 | 0d |  |
| 97 | 1.4.4.13 | Armování ŽB stropu | 4d | 2019-04-04 | 2019-04-08 | 96SS+2d | 0d |  |
| 98 | 1.4.4.14 | Betonáž ŽB stropu | 1d | 2019-04-09 | 2019-04-09 | 82, 97 | 0d |  |
| 99 | 1.4.4.15 | Odbednění ŽB stropu | 1d | 2019-04-15 | 2019-04-15 | 83, 98FS+5ed | 40d | 3d |

| ID | WBS | Task | Duration | Start | Finish | Predecessors | Total slack | Free slack |
| --- | --- | --- | --- | --- | --- | --- | --- | --- |
| 100 | 1.4.5 | **2.NP - sekce B** | 22d | 2019-04-02 | 2019-04-26 |  | 4d |  |
| 101 | 1.4.5.1 | Bednění ŽB stěny | 3d | 2019-04-06 | 2019-04-09 | 96, 93 | 0d |  |
| 102 | 1.4.5.2 | Armování ŽB stěny | 4d | 2019-04-09 | 2019-04-12 | 97, 101SS+2d | 0d |  |
| 103 | 1.4.5.3 | Dobednění ŽB stěny | 3d | 2019-04-11 | 2019-04-13 | 102SS+2d, 113 | 0d |  |
| 104 | 1.4.5.4 | Betonáž ŽB stěny | 1d | 2019-04-15 | 2019-04-15 | 103 | 0d |  |
| 105 | 1.4.5.5 | Odbednění ŽB stěny | 1d | 2019-04-19 | 2019-04-19 | 104FS+3ed, 99 | 37d | 5d |
| 106 | 1.4.5.6 | Zdění nosného zdiva | 3d | 2019-04-02 | 2019-04-04 | 94 | 4d |  |
| 107 | 1.4.5.7 | Podstojkování ŽB stropu | 1d | 2019-04-16 | 2019-04-16 | 106, 104 | 0d |  |
| 108 | 1.4.5.8 | Bednění ŽB stropu | 2d | 2019-04-16 | 2019-04-17 | 107SS, 115 | 0d |  |
| 109 | 1.4.5.9 | Armování ŽB stropu | 3d | 2019-04-17 | 2019-04-19 | 108SS+1d | 0d |  |
| 110 | 1.4.5.10 | Betonáž ŽB stropu | 1d | 2019-04-20 | 2019-04-20 | 109 | 0d |  |
| 111 | 1.4.5.11 | Odbednění ŽB stropu | 1d | 2019-04-26 | 2019-04-26 | 110FS+5ed, 105 | 32d | 3d |
| 112 | 1.4.6 | **3.NP - sekce A** | 19d | 2019-04-10 | 2019-05-01 |  | 0d |  |
| 113 | 1.4.6.1 | Bednění ŽB šachty | 1d | 2019-04-10 | 2019-04-10 | 98, 101 | 0d |  |
| 114 | 1.4.6.2 | Armování ŽB šachty | 1d | 2019-04-13 | 2019-04-13 | 102, 113 | 0d |  |
| 115 | 1.4.6.3 | Dobednění ŽB šachty | 1d | 2019-04-15 | 2019-04-15 | 114, 103 | 0d |  |
| 116 | 1.4.6.4 | Betonáž ŽB šachty | 1d | 2019-04-16 | 2019-04-16 | 115, 104 | 0d |  |
| 117 | 1.4.6.5 | Odbednění ŽB šachty | 1d | 2019-04-20 | 2019-04-20 | 116FS+3ed | 37d | 8d |
| 118 | 1.4.6.6 | Zdění nosného zdiva | 7d | 2019-04-10 | 2019-04-17 | 98, 106 | 0d |  |
| 119 | 1.4.6.7 | Podstojkování ŽB stropu | 2d | 2019-04-17 | 2019-04-18 | 107, 116 | 0d |  |
| 120 | 1.4.6.8 | Bednění ŽB stropu | 4d | 2019-04-18 | 2019-04-22 | 119SS+1d, 108, 118 | 0d |  |
| 121 | 1.4.6.9 | Armování ŽB stropu | 4d | 2019-04-20 | 2019-04-24 | 120SS+2d, 109 | 0d |  |
| 122 | 1.4.6.10 | Betonáž ŽB stropu | 1d | 2019-04-25 | 2019-04-25 | 121 | 0d |  |
| 123 | 1.4.6.11 | Odbednění ŽB stropu | 1d | 2019-05-01 | 2019-05-01 | 117, 122FS+5ed, 111 | 29d | 4d |

| ID | WBS | Task | Duration | Start | Finish | Predecessors | Total slack | Free slack |
| --- | --- | --- | --- | --- | --- | --- | --- | --- |
| 124 | 1.4.7 | **3.NP - sekce B** | 14d | 2019-04-22 | 2019-05-07 |  | 0d |  |
| 125 | 1.4.7.1 | Zdění nosného zdiva | 4d | 2019-04-22 | 2019-04-25 | 110 | 0d |  |
| 126 | 1.4.7.2 | Podstojkování ŽB stropu | 1d | 2019-04-25 | 2019-04-25 | 125SS+3d, 121 | 0d |  |
| 127 | 1.4.7.3 | Bednění ŽB stropu | 2d | 2019-04-26 | 2019-04-27 | 126, 120 | 0d |  |
| 128 | 1.4.7.4 | Armování ŽB stropu | 3d | 2019-04-27 | 2019-04-30 | 127SS+1d | 0d |  |
| 129 | 1.4.7.5 | Betonáž ŽB stropu | 1d | 2019-05-01 | 2019-05-01 | 128 | 0d |  |
| 130 | 1.4.7.6 | Odbednění ŽB stropu | 1d | 2019-05-07 | 2019-05-07 | 129FS+5ed, 123 | 25d | 7d |
| 131 | 1.4.8 | **4.NP - sekce A** | 18d | 2019-04-26 | 2019-05-16 |  | 0d |  |
| 132 | 1.4.8.1 | Bednění ŽB šachty | 1d | 2019-04-29 | 2019-04-29 | 122, 127 | 1d |  |
| 133 | 1.4.8.2 | Armování ŽB šachty | 1d | 2019-05-01 | 2019-05-01 | 132, 128 | 0d |  |
| 134 | 1.4.8.3 | Dobednění ŽB šachty | 1d | 2019-05-02 | 2019-05-02 | 132, 133 | 0d |  |
| 135 | 1.4.8.4 | Betonáž ŽB šachty | 1d | 2019-05-03 | 2019-05-03 | 134 | 23d | 0d |
| 136 | 1.4.8.5 | Odbednění ŽB šachty | 1d | 2019-05-07 | 2019-05-07 | 135FS+3ed | 25d | 7d |
| 137 | 1.4.8.6 | Zdění nosného zdiva | 7d | 2019-04-26 | 2019-05-03 | 122, 125 | 0d |  |
| 138 | 1.4.8.7 | Podstojkování ŽB stropu | 2d | 2019-05-02 | 2019-05-03 | 137SS+5d | 0d |  |
| 139 | 1.4.8.8 | Bednění ŽB stropu | 4d | 2019-05-03 | 2019-05-07 | 134, 138SS+1d | 0d |  |
| 140 | 1.4.8.9 | Armování ŽB stropu | 4d | 2019-05-06 | 2019-05-09 | 133, 139SS+2d | 0d |  |
| 141 | 1.4.8.10 | Betonáž ŽB stropu | 1d | 2019-05-10 | 2019-05-10 | 135, 140 | 18d | 0d |
| 142 | 1.4.8.11 | Odbednění ŽB stropu | 1d | 2019-05-16 | 2019-05-16 | 141FS+5ed, 130, 136 | 18d | 2d |
| 143 | 1.4.9 | **4.NP - sekce B** | 14d | 2019-05-04 | 2019-05-20 |  | 0d |  |
| 144 | 1.4.9.1 | Zdění nosného zdiva | 4d | 2019-05-04 | 2019-05-08 | 129, 137 | 0d |  |
| 145 | 1.4.9.2 | Podstojkování ŽB stropu | 1d | 2019-05-08 | 2019-05-08 | 144SS+3d | 0d |  |
| 146 | 1.4.9.3 | Bednění ŽB stropu | 2d | 2019-05-09 | 2019-05-10 | 145, 139 | 0d |  |
| 147 | 1.4.9.4 | Armování ŽB stropu | 3d | 2019-05-10 | 2019-05-13 | 146SS+1d, 140 | 0d |  |
| 148 | 1.4.9.5 | Betonáž ŽB stropu | 1d | 2019-05-14 | 2019-05-14 | 147 | 0d |  |
| 149 | 1.4.9.6 | Odbednění ŽB stropu | 1d | 2019-05-20 | 2019-05-20 | 148FS+5ed, 142 | 16d | 1d |

| ID | WBS | Task | Duration | Start | Finish | Predecessors | Total slack | Free slack |
| --- | --- | --- | --- | --- | --- | --- | --- | --- |
| 150 | 1.4.10 | **Střecha** | 7d | 2019-05-15 | 2019-05-22 |  | 0d |  |
| 151 | 1.4.10.1 | Bednění ŽB atiky | 1d | 2019-05-15 | 2019-05-15 | 146, 148 | 0d |  |
| 152 | 1.4.10.2 | Armování ŽB atiky | 1d | 2019-05-16 | 2019-05-16 | 151, 147 | 0d |  |
| 153 | 1.4.10.3 | Dobednění ŽB atiky | 1d | 2019-05-17 | 2019-05-17 | 151, 152 | 0d |  |
| 154 | 1.4.10.4 | Betonáž ŽB atiky | 1d | 2019-05-18 | 2019-05-18 | 153 | 0d |  |
| 155 | 1.4.10.5 | Odbednění ŽB atiky | 1d | 2019-05-22 | 2019-05-22 | 149, 154FS+3ed | 15d | 0d |
| 156 | 1.4.11 | Demontáž jeřábu | 1d | 2019-05-23 | 2019-05-23 | 155 | 15d | 0d |
| 157 | 1.4.12 | Montáž stavevního výtahu | 1d | 2019-05-24 | 2019-05-24 | 156 | 15d | 6d |
| 158 | 1.5 | **Odstojkování ŽB stropu** | 36d | 2019-05-02 | 2019-06-12 |  | 0d |  |
| 159 | 1.5.1 | 1A - Odstojkování ŽB stropu | 1d | 2019-05-02 | 2019-05-02 | 65FS+28ed, 129 | 0d |  |
| 160 | 1.5.2 | 1B - Odstojkování ŽB stropu | 1d | 2019-05-03 | 2019-05-03 | 82FS+28ed, 159 | 0d |  |
| 161 | 1.5.3 | 2A - Odstojkování ŽB stropu | 1d | 2019-05-11 | 2019-05-11 | 98FS+28ed, 141, 160 | 50d | 6d |
| 162 | 1.5.4 | 2B - Odstojkování ŽB stropu | 1d | 2019-05-20 | 2019-05-20 | 110FS+28ed, 161 | 44d | 3d |
| 163 | 1.5.5 | 3A - Odstojkování ŽB stropu | 1d | 2019-05-24 | 2019-05-24 | 122FS+28ed, 162 | 41d | 4d |
| 164 | 1.5.6 | 3B - Odstojkování ŽB stropu | 1d | 2019-05-30 | 2019-05-30 | 129FS+28ed, 163 | 37d | 7d |
| 165 | 1.5.7 | 4A - Odstojkování ŽB stropu | 1d | 2019-06-08 | 2019-06-08 | 141FS+28ed, 164 | 30d | 2d |
| 166 | 1.5.8 | 4B - Odstojkování ŽB stropu | 1d | 2019-06-12 | 2019-06-12 | 148FS+28ed, 165 | 28d | 15d |
| 167 | 1.6 | **Zastřešení** | 30d | 2019-05-20 | 2019-06-22 |  | 0d |  |
| 168 | 1.6.1 | Osazení střešních výlezů | 3d | 2019-05-20 | 2019-05-22 | 154 | 1d |  |
| 169 | 1.6.2 | Záchytný systém | 4d | 2019-05-20 | 2019-05-23 | 154 | 0d |  |
| 170 | 1.6.3 | Tepelná izolace nad plochou střechou | 8d | 2019-05-24 | 2019-06-01 | 168, 169 | 0d |  |
| 171 | 1.6.4 | Provedení hydroizolační fólie | 18d | 2019-06-03 | 2019-06-22 | 170, 210, 211, 212, 213 | 0d |  |
| 172 | 1.7 | **Příčky a hrubé instalace** | 80d | 2019-05-04 | 2019-08-05 |  | 0d |  |
| 173 | 1.7.1 | **1.NP** | 42d | 2019-05-04 | 2019-06-21 |  | 0d |  |
| 174 | 1.7.1.1 | Příčkové zdivo | 8d | 2019-05-04 | 2019-05-13 | 160 | 0d |  |
| 175 | 1.7.1.2 | Hrubé elektro rozvody | 18d | 2019-05-14 | 2019-06-03 | 174 | 0d |  |
| 176 | 1.7.1.3 | Hrubé rozvody vzduchotechniky | 10d | 2019-05-13 | 2019-05-23 | 174FS-1d | 2d | 0d |
| 177 | 1.7.1.4 | Hrubé kanalizační rozvody | 10d | 2019-05-27 | 2019-06-06 | 174FS+11d, 212 | 13d | 0d |
| 178 | 1.7.1.5 | Hrubé vodovodní rozvody | 10d | 2019-06-03 | 2019-06-13 | 174FS+17d | 7d | 0d |
| 179 | 1.7.1.6 | Hrubé rozvody plynu | 10d | 2019-05-29 | 2019-06-08 | 174FS+13d, 213 | 11d | 0d |
| 180 | 1.7.1.7 | Hrubé topen. rozvody | 10d | 2019-06-11 | 2019-06-21 | 174FS+24d | 0d |  |
| 181 | 1.7.1.8 | Osazení oken a balkonových dveří | 1d | 2019-06-11 | 2019-06-11 | 201 | 9d | 0d |

| ID | WBS | Task | Duration | Start | Finish | Predecessors | Total slack | Free slack |
| --- | --- | --- | --- | --- | --- | --- | --- | --- |
| 182 | 1.7.2 | **2.NP** | 44d | 2019-05-14 | 2019-07-03 |  | 9d |  |
| 183 | 1.7.2.1 | Příčkové zdivo | 8d | 2019-05-14 | 2019-05-22 | 174 | 9d | 0d |
| 184 | 1.7.2.2 | Hrubé elektro rozvody | 18d | 2019-06-04 | 2019-06-24 | 175, 210, 183 | 0d |  |
| 185 | 1.7.2.3 | Hrubé rozvody vzduchotechniky | 5d | 2019-05-31 | 2019-06-05 | 211, 183 | 34d | 0d |
| 186 | 1.7.2.4 | Hrubé kanalizační rozvody | 10d | 2019-06-07 | 2019-06-18 | 177, 183 | 13d | 0d |
| 187 | 1.7.2.5 | Hrubé vodovodní rozvody | 10d | 2019-06-14 | 2019-06-25 | 178, 183 | 7d | 0d |
| 188 | 1.7.2.6 | Hrubé rozvody plynu | 10d | 2019-06-10 | 2019-06-20 | 179, 183 | 11d | 0d |
| 189 | 1.7.2.7 | Hrubé topen. rozvody | 10d | 2019-06-22 | 2019-07-03 | 180, 183 | 0d |  |
| 190 | 1.7.2.8 | Osazení oken a balkonových dveří | 1d | 2019-06-12 | 2019-06-12 | 181 | 36d | 0d |
| 191 | 1.7.3 | **3.NP** | 46d | 2019-05-23 | 2019-07-15 |  | 9d |  |
| 192 | 1.7.3.1 | Příčkové zdivo | 8d | 2019-05-23 | 2019-05-31 | 183 | 9d | 0d |
| 193 | 1.7.3.2 | Hrubé elektro rozvody | 18d | 2019-06-25 | 2019-07-15 | 184, 192 | 0d |  |
| 194 | 1.7.3.3 | Hrubé rozvody vzduchotechniky | 5d | 2019-06-06 | 2019-06-11 | 185, 192 | 34d | 0d |
| 195 | 1.7.3.4 | Hrubé kanalizační rozvody | 10d | 2019-06-19 | 2019-06-29 | 186, 192 | 13d | 0d |
| 196 | 1.7.3.5 | Hrubé vodovodní rozvody | 10d | 2019-06-26 | 2019-07-06 | 187, 192 | 7d | 0d |
| 197 | 1.7.3.6 | Hrubé rozvody plynu | 10d | 2019-06-21 | 2019-07-02 | 188, 192 | 11d | 0d |
| 198 | 1.7.3.7 | Hrubé topen. rozvody | 10d | 2019-07-04 | 2019-07-15 | 189, 192 | 0d |  |
| 199 | 1.7.3.8 | Osazení oken a balkonových dveří | 1d | 2019-06-13 | 2019-06-13 | 190 | 36d | 0d |
| 200 | 1.7.4 | **4.NP** | 56d | 2019-06-01 | 2019-08-05 |  | 0d |  |
| 201 | 1.7.4.1 | Příčkové zdivo | 8d | 2019-06-01 | 2019-06-10 | 157, 192 | 9d | 0d |
| 202 | 1.7.4.2 | Hrubé elektro rozvody | 18d | 2019-07-16 | 2019-08-05 | 193, 201 | 0d |  |
| 203 | 1.7.4.3 | Hrubé rozvody vzduchotechniky | 5d | 2019-06-12 | 2019-06-17 | 194, 201 | 34d |  |
| 204 | 1.7.4.4 | Hrubé kanalizační rozvody | 10d | 2019-07-01 | 2019-07-11 | 166, 195, 201 | 13d |  |
| 205 | 1.7.4.5 | Hrubé vodovodní rozvody | 10d | 2019-07-08 | 2019-07-18 | 196, 201 | 7d |  |
| 206 | 1.7.4.6 | Hrubé rozvody plynu | 10d | 2019-07-03 | 2019-07-13 | 197, 201 | 11d |  |
| 207 | 1.7.4.7 | Hrubé topen. rozvody | 10d | 2019-07-16 | 2019-07-26 | 198, 201 | 0d |  |
| 208 | 1.7.4.8 | Osazení oken a balkonových dveří | 1d | 2019-06-14 | 2019-06-14 | 199 | 36d |  |

| ID | WBS | Task | Duration | Start | Finish | Predecessors | Total slack | Free slack |
| --- | --- | --- | --- | --- | --- | --- | --- | --- |
| 209 | 1.7.5 | **střecha** | 6d | 2019-05-24 | 2019-05-30 |  | 2d |  |
| 210 | 1.7.5.1 | Hrubé elektro rozvody | 4d | 2019-05-24 | 2019-05-28 | 169 | 4d |  |
| 211 | 1.7.5.2 | Hrubé rozvody vzduchotechniky | 6d | 2019-05-24 | 2019-05-30 | 176, 169 | 2d | 0d |
| 212 | 1.7.5.3 | Hrubé kanalizační rozvody | 2d | 2019-05-24 | 2019-05-25 | 169 | 6d | 0d |
| 213 | 1.7.5.4 | Hrubé rozvody komínů | 4d | 2019-05-24 | 2019-05-28 | 169 | 4d | 0d |
| 214 | 1.8 | **Vnitřní úpravy povrchů** | 84d | 2019-06-22 | 2019-09-27 |  | 0d |  |
| 215 | 1.8.1 | **1.NP** | 73d | 2019-06-22 | 2019-09-14 |  | 0d |  |
| 216 | 1.8.1.1 | Provedení omítky | 10d | 2019-06-22 | 2019-07-03 | 181, 180, 171FS-1d | 0d |  |
| 217 | 1.8.1.2 | Tepelné izolace podlahy | 4d | 2019-07-04 | 2019-07-08 | 216 | 0d |  |
| 218 | 1.8.1.3 | Montáž podlahových konvektorů | 2d | 2019-07-06 | 2019-07-08 | 217SS+2d | 0d |  |
| 219 | 1.8.1.4 | Samonivelační potěr | 2d | 2019-07-09 | 2019-07-10 | 217, 218 | 0d |  |
| 220 | 1.8.1.5 | Provedení SDK příčky | 10d | 2019-07-12 | 2019-07-23 | 219FS+1d | 0d |  |
| 221 | 1.8.1.6 | Montáž SDK podhledu | 5d | 2019-07-30 | 2019-08-03 | 230 | 0d |  |
| 222 | 1.8.1.7 | Montáž kazetového podhledu | 3d | 2019-08-17 | 2019-08-20 | 248 | 0d |  |
| 223 | 1.8.1.8 | Provedení obkladů | 4d | 2019-08-06 | 2019-08-09 | 221, 231 | 0d |  |
| 224 | 1.8.1.9 | Provedení keramické dlažby | 8d | 2019-09-06 | 2019-09-14 | 258FS+9d | 0d |  |
| 225 | 1.8.2 | **2.NP** | 58d | 2019-07-04 | 2019-09-09 |  | 0d |  |
| 226 | 1.8.2.1 | Provedení omítky | 10d | 2019-07-04 | 2019-07-15 | 216 | 0d |  |
| 227 | 1.8.2.2 | Tepelné izolace podlahy | 4d | 2019-07-16 | 2019-07-19 | 226 | 0d |  |
| 228 | 1.8.2.3 | Montáž podlahových konvektorů | 2d | 2019-07-18 | 2019-07-19 | 227SS+2d | 0d |  |
| 229 | 1.8.2.4 | Samonivelační potěr | 2d | 2019-07-20 | 2019-07-22 | 227, 228 | 0d |  |
| 230 | 1.8.2.5 | Montáž SDK podhledu | 5d | 2019-07-24 | 2019-07-29 | 220, 229FS+1d | 0d |  |
| 231 | 1.8.2.6 | Provedení obkladů | 6d | 2019-07-30 | 2019-08-05 | 230 | 0d |  |
| 232 | 1.8.2.7 | Provedení keramické dlažby | 9d | 2019-08-24 | 2019-09-03 | 249, 229SS+35ed | 0d |  |
| 233 | 1.8.2.8 | Provedení plovoucí podlahy | 8d | 2019-08-31 | 2019-09-09 | 232FS-3d | 0d |  |

| ID | WBS | Task | Duration | Start | Finish | Predecessors | Total slack | Free slack |
| --- | --- | --- | --- | --- | --- | --- | --- | --- |
| 234 | 1.8.3 | **3.NP** | 56d | 2019-07-16 | 2019-09-18 |  | 0d |  |
| 235 | 1.8.3.1 | Provedení omítky | 10d | 2019-07-16 | 2019-07-26 | 226 | 0d |  |
| 236 | 1.8.3.2 | Tepelné izolace podlahy | 4d | 2019-07-27 | 2019-07-31 | 235 | 0d |  |
| 237 | 1.8.3.3 | Montáž podlahových konvektorů | 2d | 2019-07-30 | 2019-07-31 | 236SS+2d | 0d |  |
| 238 | 1.8.3.4 | Samonivelační potěr | 2d | 2019-08-01 | 2019-08-02 | 237, 236 | 0d |  |
| 239 | 1.8.3.5 | Montáž SDK podhledu | 5d | 2019-08-05 | 2019-08-09 | 221, 238FS+1d | 0d |  |
| 240 | 1.8.3.6 | Provedení obkladů | 6d | 2019-08-10 | 2019-08-16 | 223, 239 | 0d |  |
| 241 | 1.8.3.7 | Provedení keramické dlažby | 9d | 2019-09-04 | 2019-09-13 | 232, 238SS+34ed | 0d |  |
| 242 | 1.8.3.8 | Provedení plovoucí podlahy | 8d | 2019-09-10 | 2019-09-18 | 233 | 0d |  |
| 243 | 1.8.4 | **4.NP** | 54d | 2019-07-27 | 2019-09-27 |  | 0d |  |
| 244 | 1.8.4.1 | Provedení omítky | 10d | 2019-07-27 | 2019-08-07 | 202SS+10d, 203, 204, 205, 206, 207, 208, 235 | 0d |  |
| 245 | 1.8.4.2 | Tepelné izolace podlahy | 4d | 2019-08-05 | 2019-08-08 | 244FS-3d | 0d |  |
| 246 | 1.8.4.3 | Montáž podlahových konvektorů | 2d | 2019-08-07 | 2019-08-08 | 245SS+2d | 0d |  |
| 247 | 1.8.4.4 | Samonivelační potěr | 2d | 2019-08-09 | 2019-08-10 | 245, 246 | 0d |  |
| 248 | 1.8.4.5 | Montáž SDK podhledu | 5d | 2019-08-12 | 2019-08-16 | 239, 247FS+1ed | 0d |  |
| 249 | 1.8.4.6 | Provedení obkladů | 6d | 2019-08-17 | 2019-08-23 | 248, 240 | 0d |  |
| 250 | 1.8.4.7 | Provedení keramické dlažby | 9d | 2019-09-14 | 2019-09-24 | 241, 247SS+35ed | 0d |  |
| 251 | 1.8.4.8 | Provedení plovoucí podlahy | 8d | 2019-09-19 | 2019-09-27 | 250SS+4d, 242 | 0d |  |
| 252 | 1.9 | **Vnitřní kompletace** | 46d | 2019-08-09 | 2019-10-01 |  | 0d |  |
| 253 | 1.9.1 | Montáž výtahů | 35d | 2019-08-09 | 2019-09-18 | 244FS+1d | 8d |  |
| 254 | 1.9.2 | **1.NP** | 30d | 2019-08-17 | 2019-09-20 |  | 0d |  |
| 255 | 1.9.2.1 | Kompletace elektro | 5d | 2019-08-20 | 2019-08-24 | 222FS-1d | 15d | 0d |
| 256 | 1.9.2.2 | Kompletace vzduchotechniky | 5d | 2019-08-24 | 2019-08-29 | 222FS+3d | 22d | 0d |
| 257 | 1.9.2.3 | Kompletace sanita | 2d | 2019-09-16 | 2019-09-17 | 224 | 0d |  |
| 258 | 1.9.2.4 | Kompletace kotelny | 8d | 2019-08-17 | 2019-08-26 | 222SS | 0d |  |
| 259 | 1.9.2.5 | Kompletace topení | 1d | 2019-08-27 | 2019-08-27 | 258 | 20d | 0d |
| 260 | 1.9.2.6 | Osazení parapetů | 1d | 2019-08-22 | 2019-08-22 | 222FS+1d | 11d | 0d |
| 261 | 1.9.2.7 | Osazení dveřních křídel | 1d | 2019-09-18 | 2019-09-18 | 257 | 0d |  |
| 262 | 1.9.2.8 | Montáž zábradlí | 1d | 2019-09-04 | 2019-09-04 | 232 | 17d | 0d |
| 263 | 1.9.2.9 | Malířské práce | 5d | 2019-08-23 | 2019-08-28 | 260 | 11d | 0d |
| 264 | 1.9.2.10 | Vyčištění podlaží | 3d | 2019-09-18 | 2019-09-20 | 255, 257, 222, 224 | 0d |  |

| ID | WBS | Task | Duration | Start | Finish | Predecessors | Total slack | Free slack |
| --- | --- | --- | --- | --- | --- | --- | --- | --- |
| 265 | 1.9.3 | **2.NP** | 28d | 2019-08-23 | 2019-09-24 |  | 1d |  |
| 266 | 1.9.3.1 | Kompletace elektro | 4d | 2019-08-26 | 2019-08-29 | 255 | 15d | 0d |
| 267 | 1.9.3.2 | Kompletace vzduchotechniky | 1d | 2019-08-30 | 2019-08-30 | 256 | 22d | 0d |
| 268 | 1.9.3.3 | Kompletace sanita | 3d | 2019-09-18 | 2019-09-20 | 257 | 0d |  |
| 269 | 1.9.3.4 | Kompletace topení | 1d | 2019-08-28 | 2019-08-28 | 259 | 20d | 0d |
| 270 | 1.9.3.5 | Osazení parapetů | 1d | 2019-08-23 | 2019-08-23 | 260 | 28d | 0d |
| 271 | 1.9.3.6 | Osazení dveřních křídel | 3d | 2019-09-19 | 2019-09-21 | 261 | 0d |  |
| 272 | 1.9.3.7 | Montáž zábradlí | 1d | 2019-09-05 | 2019-09-05 | 262 | 17d | 0d |
| 273 | 1.9.3.8 | Malířské práce | 5d | 2019-08-29 | 2019-09-03 | 263 | 11d | 0d |
| 274 | 1.9.3.9 | Vyčištění podlaží | 3d | 2019-09-21 | 2019-09-24 | 266, 268, 264 | 0d |  |
| 275 | 1.9.4 | **3.NP** | 30d | 2019-08-24 | 2019-09-27 |  | 0d |  |
| 276 | 1.9.4.1 | Kompletace elektro | 4d | 2019-08-30 | 2019-09-03 | 266 | 15d | 0d |
| 277 | 1.9.4.2 | Kompletace vzduchotechniky | 1d | 2019-08-31 | 2019-08-31 | 267 | 22d | 0d |
| 278 | 1.9.4.3 | Kompletace sanita | 3d | 2019-09-21 | 2019-09-24 | 268 | 0d |  |
| 279 | 1.9.4.4 | Kompletace topení | 1d | 2019-08-29 | 2019-08-29 | 269 | 20d | 0d |
| 280 | 1.9.4.5 | Osazení parapetů | 1d | 2019-08-24 | 2019-08-24 | 270 | 28d | 0d |
| 281 | 1.9.4.6 | Osazení dveřních křídel | 3d | 2019-09-23 | 2019-09-25 | 271 | 0d |  |
| 282 | 1.9.4.7 | Montáž zábradlí | 1d | 2019-09-06 | 2019-09-06 | 272 | 17d | 0d |
| 283 | 1.9.4.8 | Malířské práce | 5d | 2019-09-04 | 2019-09-09 | 273 | 11d | 0d |
| 284 | 1.9.4.9 | Vyčištění podlaží | 3d | 2019-09-25 | 2019-09-27 | 276, 278, 274 | 0d |  |
| 285 | 1.9.5 | **4.NP** | 32d | 2019-08-26 | 2019-10-01 |  | 0d |  |
| 286 | 1.9.5.1 | Kompletace elektro | 4d | 2019-09-04 | 2019-09-07 | 276 | 15d | 0d |
| 287 | 1.9.5.2 | Kompletace vzduchotechniky | 1d | 2019-09-02 | 2019-09-02 | 277 | 22d |  |
| 288 | 1.9.5.3 | Kompletace sanita | 3d | 2019-09-25 | 2019-09-27 | 250, 278 | 0d |  |
| 289 | 1.9.5.4 | Kompletace topení | 1d | 2019-08-30 | 2019-08-30 | 279 | 20d | 0d |
| 290 | 1.9.5.5 | Osazení parapetů | 1d | 2019-08-26 | 2019-08-26 | 280 | 28d |  |
| 291 | 1.9.5.6 | Osazení dveřních křídel | 3d | 2019-09-26 | 2019-09-28 | 281 | 0d |  |
| 292 | 1.9.5.7 | Montáž zábradlí | 1d | 2019-09-07 | 2019-09-07 | 282 | 17d |  |
| 293 | 1.9.5.8 | Malířské práce | 5d | 2019-09-10 | 2019-09-14 | 283 | 11d |  |
| 294 | 1.9.5.9 | Vyčištění podlaží | 3d | 2019-09-28 | 2019-10-01 | 251, 253, 286, 287, 288, 292, 289, 290, 291FS-1d, 284, 293 | 0d |  |

| ID | WBS | Task | Type | Duration | Start | Finish | Predecessors | Total slack | Free slack |
| --- | --- | --- | --- | --- | --- | --- | --- | --- | --- |
| 295 | 1.9.6 | **střecha** |  | 5d | 2019-09-09 | 2019-09-13 |  | 15d |  |
| 296 | 1.9.6.1 | Kompletace elektro |  | 5d | 2019-09-09 | 2019-09-13 | 286 | 15d |  |
| 297 | 1.9.7 | topná zkouška |  | 7d | 2019-08-31 | 2019-09-07 | 289 | 20d |  |
| 298 | 1.10 | **Vnější úpravy** |  | 88d | 2019-06-25 | 2019-10-04 |  | 0d |  |
| 299 | 1.10.1 | Montáž lešení |  | 6d | 2019-06-25 | 2019-07-01 | 171FS+1d | 0d |  |
| 300 | 1.10.2 | Zakrytí oken fólií |  | 2d | 2019-07-02 | 2019-07-03 | 299 | 0d |  |
| 301 | 1.10.3 | Provedení tep. izolace (vnější omítka) |  | 2d | 2019-07-03 | 2019-07-04 | 300FS-1d | 23d |  |
| 302 | 1.10.4 | Provedení omítky vyztužené tkaninou |  | 24d | 2019-07-04 | 2019-07-31 | 300 | 0d |  |
| 303 | 1.10.5 | Osazení vnějších parapetů |  | 5d | 2019-07-29 | 2019-08-02 | 302FS-3d | 0d |  |
| 304 | 1.10.6 | Provedení vnější omítky |  | 11d | 2019-08-01 | 2019-08-13 | 302, 303FS-2d, 301 | 0d |  |
| 305 | 1.10.7 | Okenní skleněné zábradlí |  | 3d | 2019-08-14 | 2019-08-16 | 304 | 2d |  |
| 306 | 1.10.8 | Klempířské práce |  | 5d | 2019-08-14 | 2019-08-19 | 304 | 0d |  |
| 307 | 1.10.9 | Demontáž stavebního výtahu |  | 1d | 2019-08-17 | 2019-08-17 | 240 | 1d |  |
| 308 | 1.10.10 | Demontáž lešení |  | 4d | 2019-08-20 | 2019-08-23 | 305, 306, 307 | 0d |  |
| 309 | 1.10.11 | Vyrovnávací stěrky bakonů |  | 6d | 2019-08-24 | 2019-08-30 | 308 | 21d | 0d |
| 310 | 1.10.12 | Protiskluzná povrchová úprava balkonů |  | 6d | 2019-08-31 | 2019-09-06 | 309 | 21d |  |
| 311 | 1.10.13 | Tepelná izolace teras |  | 3d | 2019-08-24 | 2019-08-27 | 308 | 18d | 0d |
| 312 | 1.10.14 | Hydroizolační fólie teras |  | 3d | 2019-08-28 | 2019-08-30 | 311 | 18d | 0d |
| 313 | 1.10.15 | Dlažba na terčích terasy |  | 5d | 2019-08-31 | 2019-09-05 | 312 | 18d | 0d |
| 314 | 1.10.16 | Montáž dělících příček |  | 4d | 2019-09-06 | 2019-09-10 | 313 | 18d |  |
| 315 | 1.10.17 | Provedení přípojky - splašková kanalizace |  | 10d | 2019-08-22 | 2019-09-02 | 308FS-2d | 0d |  |
| 316 | 1.10.18 | Provedení přípojky - vodovod |  | 10d | 2019-08-28 | 2019-09-07 | 315FS-5d | 0d |  |
| 317 | 1.10.19 | Provedení přípojky - plynovod |  | 10d | 2019-09-03 | 2019-09-13 | 316FS-5d | 0d |  |
| 318 | 1.10.20 | Provedení přípojky - elektro |  | 10d | 2019-09-05 | 2019-09-16 | 317SS+2d | 0d |  |
| 319 | 1.10.21 | Provedení přípojky - sdělovací kabel |  | 10d | 2019-09-07 | 2019-09-18 | 318SS+2d | 0d |  |
| 320 | 1.10.22 | Trativod z drenážních trubek |  | 4d | 2019-09-14 | 2019-09-18 | 318FS-2d | 0d |  |
| 321 | 1.10.23 | Svislá hydroizolace | manual | 1d | 2019-09-18 | 2019-09-18 | 320FS-1d |  |  |
| 322 | 1.10.24 | Tepelná izolace soklu |  | 1d | 2019-09-19 | 2019-09-19 | 321 | 0d |  |
| 323 | 1.10.25 | Postupně hutněný zásyp |  | 1d | 2019-09-20 | 2019-09-20 | 322 | 0d |  |
| 324 | 1.10.26 | Provedení omítky vyztužené tkaninou |  | 1d | 2019-09-21 | 2019-09-21 | 323 | 0d |  |
| 325 | 1.10.27 | Marmolit |  | 1d | 2019-09-27 | 2019-09-27 | 324FS+5ed | 1d | 0d |
| 326 | 1.10.28 | Okapový chodník |  | 2d | 2019-09-28 | 2019-09-30 | 328, 325 | 1d |  |
| 327 | 1.10.29 | Provedení asfaltového krytu |  | 3d | 2019-09-11 | 2019-09-13 | 318SS+5d | 15d |  |
| 328 | 1.10.30 | Zámková dlažba |  | 13d | 2019-09-13 | 2019-09-27 | 319SS+5d | 0d |  |
| 329 | 1.10.31 | Odstranění zařízení staveniště |  | 3d | 2019-09-27 | 2019-09-30 | 328FS-1d | 1d |  |
| 330 | 1.10.32 | Úprava terénu |  | 8d | 2019-09-23 | 2019-10-01 | 328FS-5d, 242 | 0d |  |
| 331 | 1.10.33 | Předání stavby |  | 2d | 2019-10-02 | 2019-10-03 | 294, 296, 310, 314, 327, 326, 329, 330, 319, 297 | 0d |  |
| 332 | 1.10.34 | Kolaudace |  | 1d | 2019-10-04 | 2019-10-04 | 331 | 0d |  |
